# LCLS II at the LERF

Schedule from MS Project, 2017-09-01 to 2020-01-15.
JLAB

## Calendars

- Standard: Mon-Fri 08:00-12:00, 13:00-17:00; Sat-Sun off.

## Resources

| Resource |
| --- |
| Inst./Vac |
| Vac/SRF |
| Inst |
| Cryo |
| EESRF |
| SRF |
| Align |

## Schedule

| ID | WBS | Task | Type | Duration | Start | Finish | Predecessors |
| --- | --- | --- | --- | --- | --- | --- | --- |
| 1 | 1 | **Design** |  | 619d | 2017-09-01 | 2020-01-15 |  |
| 2 | 1.1 | Define Stands, ETC to be removed | manual | 3d | 2017-09-01 | 2017-09-05 |  |
| 3 | 1.2 | Evaluate Test Configuration | manual | 14d | 2017-09-13 | 2017-10-02 | 2SS |
| 4 | 1.3 | Design/Engineering of New End Cans | manual | 20d | 2017-09-13 | 2017-10-10 | 3SS |
| 5 | 1.4 | Design Wave Guides | manual | 10d | 2017-09-27 | 2017-10-10 | 4FF |
| 6 | 1.5 | Waveguide design review | manual | 1d | 2017-10-11 | 2017-10-11 | 5 |
| 7 | 1.6 | Egress evaluation for LERF Gallery space | manual | 2d | 2017-09-20 | 2017-09-21 |  |
| 8 | 1.7 | Modify Design of Clean room for CM work in tunnel | manual | 3d | 2017-09-26 | 2017-09-28 |  |
| 9 | 1.8 | Conduct Final Design Review of New Hardware | manual | 2d | 2017-10-10 | 2017-10-11 | 5, 4 |
| 10 | 1.9 | COMP: LERF New Hardware FDR | manual | 1d | 2017-10-12 | 2017-10-12 | 9 |
| 11 | 1.10 | Evaluate Vault Operational Envelope to include Safety | manual | 10d | 2018-02-02 | 2018-02-15 | 9, 85 |
| 12 | 1.11 | Conduct Testing Readiness Review | manual | 2d | 2018-02-16 | 2018-02-19 | 11 |
| 13 | 1.12 | COMP: Testing Readiness Review | manual | 1d | 2018-02-20 | 2018-02-20 | 12 |
| 14 | 1.13 | Project Oversight | manual | 619d | 2017-09-01 | 2020-01-15 | 2SS |
| 15 | 2 | **Procurements** |  | 88d | 2017-10-03 | 2018-02-01 |  |
| 16 | 2.1 | RQN: Wave Guide Connections | manual | 1d | 2017-10-03 | 2017-10-03 | 3 |
| 17 | 2.2 | Prepare Award Documents | manual | 5d | 2017-10-04 | 2017-10-10 | 16 |
| 18 | 2.3 | AWARD: Wave Guide Connections | manual | 1d | 2017-10-23 | 2017-10-23 | 17 |
| 19 | 2.4 | Vendor Effort Fabricate Wave Guide Connections | manual | 60d | 2017-10-23 | 2018-01-12 | 18 |
| 20 | 2.5 | ACCEPT: Wave Guide Connections | manual | 1d | 2018-01-15 | 2018-01-15 | 19 |
| 21 | 2.6 | RQN: Two Sets Cryomodule End Caps | manual | 1d | 2017-10-16 | 2017-10-16 | 3 |
| 22 | 2.7 | Prepare Award Documents | manual | 5d | 2017-10-23 | 2017-10-27 | 21 |
| 23 | 2.8 | AWARD: Two Sets Cryomodule End Caps | manual | 1d | 2017-10-30 | 2017-10-30 | 22 |
| 24 | 2.9 | Vendor Effort Fabricate Two Sets of Cryomodule End Caps | manual | 70d | 2017-10-31 | 2018-02-05 | 23 |
| 25 | 2.10 | ACCEPT: Two Sets Cryomodule End Caps | manual | 1d | 2018-02-06 | 2018-02-06 | 24 |
| 26 | 2.11 | RQN: Clean room for CM work in tunnel | manual | 1d | 2017-10-03 | 2017-10-03 |  |
| 27 | 2.12 | ACCEPT: Clean room for CM work in tunnel | manual | 1d | 2017-12-04 | 2017-12-04 |  |
| 28 | 2.13 | RQN: Four Sets of Cryomodule Stands | manual | 1d | 2017-10-03 | 2017-10-03 | 3 |
| 29 | 2.14 | Prepare Award Documents | manual | 5d | 2017-10-04 | 2017-10-10 | 28 |
| 30 | 2.15 | AWARD: Four Sets of Cryomodule Stands | manual | 1d | 2017-10-11 | 2017-10-11 | 29 |
| 31 | 2.16 | Vendor Effort Fabricate Four Sets of Cryomodule Stands | manual | 38d | 2017-10-12 | 2017-12-04 | 30 |
| 32 | 2.17 | ACCEPT: Four Sets of Cryomodule Stands | manual | 1d | 2017-12-05 | 2017-12-05 | 31 |
| 33 | 2.18 | RQN: AC Power Upgrade | manual | 1d | 2017-10-03 | 2017-10-03 | 3 |
| 34 | 2.19 | Prepare Award Documents | manual | 5d | 2017-10-04 | 2017-10-10 | 33 |
| 35 | 2.20 | AWARD: AC Power Panel Procurement | manual | 1d | 2017-10-11 | 2017-10-11 | 34 |
| 36 | 2.21 | Vendor Effort Perform AC Power Panel procurement | manual | 18d | 2017-10-12 | 2017-11-06 | 35 |
| 37 | 2.22 | ACCEPT: AC Power Panel Procuirement | manual | 1d | 2017-12-21 | 2017-12-21 | 36 |
| 38 | 2.23 | RQN: Additional sets of Bayonet Boxes and End Cans to Support additional testing | manual | 1d | 2017-10-03 | 2017-10-03 | 3 |
| 39 | 2.24 | Prepare Award Documents | manual | 5d | 2017-10-04 | 2017-10-10 | 38 |
| 40 | 2.25 | AWARD: Additional sets of Bayonet Boxes and End Cans | manual | 1d | 2017-10-11 | 2017-10-11 | 39 |
| 41 | 2.26 | Vendor Effort Additional sets of Bayonet Boxes and End Cans | manual | 80d | 2017-10-12 | 2018-01-31 | 40 |
| 42 | 2.27 | ACCEPT: Additional sets of Bayonet Boxes and End Cans | manual | 1d | 2018-02-01 | 2018-02-01 | 41 |

| ID | WBS | Task | Type | Duration | Start | Finish | Predecessors | Resources | Work |
| --- | --- | --- | --- | --- | --- | --- | --- | --- | --- |
| 43 | 3 | **SLAC Loaner Hardware** |  | 103d | 2017-09-13 | 2018-02-02 |  |  |  |
| 44 | 3.1 | Oversight of SLAC Loaner Hardware | manual | 89d | 2017-09-13 | 2018-01-15 |  |  |  |
| 45 | 3.2 | SLAC Ship SSAs to Jlab | manual | 66d | 2017-09-13 | 2017-12-13 |  |  |  |
| 46 | 3.3 | RCV: 16 SSAs from SLAC | manual | 2d | 2017-12-14 | 2017-12-15 | 45 |  |  |
| 47 | 3.4 | Crane SSAs to LERF gallery | manual | 1d | 2017-12-18 | 2017-12-18 | 46 |  |  |
| 48 | 3.5 | SLAC Ship Isolators to JLab | manual | 23d | 2017-12-14 | 2018-01-15 | 45 |  |  |
| 49 | 3.6 | RCV: 16 Isolators from SLAC | manual | 1d | 2018-01-22 | 2018-01-22 | 48 |  |  |
| 50 | 3.7 | SLAC Ship Couplers to JLab | manual | 11d | 2017-12-01 | 2017-12-15 | 45 |  |  |
| 51 | 3.8 | RCV: 16 Dual Directional Couplers from SLAC | manual | 1d | 2017-12-18 | 2017-12-18 | 50 |  |  |
| 52 | 3.9 | SLAC ShipLLRF Racks to JLab | manual | 23d | 2017-12-14 | 2018-01-15 | 45 |  |  |
| 53 | 3.10 | RCV: Four Complete LLRF Racks (fully dressed with chassis and internal cables) from SLAC | manual | 1d | 2018-02-01 | 2018-02-01 | 52 |  |  |
| 54 | 3.11 | SLAC Ship Cryo Controls to Jlab | manual | 13d | 2017-12-14 | 2018-01-01 | 45 |  |  |
| 55 | 3.12 | RCV: Two Complete Cryo Controls Racks (fully dressed with equipment) from SLAC | manual | 1d | 2018-01-02 | 2018-01-02 | 54 |  |  |
| 56 | 3.13 | SLAC Ship Vacuum Controls to JLab | manual | 13d | 2017-12-14 | 2018-01-01 | 45 |  |  |
| 57 | 3.14 | RCV: Beam line, Coupler and Inslating Vacuum Control Racks (fully dressed with equipment) from SLAC | manual | 1d | 2018-01-02 | 2018-01-02 | 56 |  |  |
| 58 | 4 | **LERF Set-up** |  | 142d | 2017-10-03 | 2018-04-18 |  |  | 664h |
| 59 | 4.1 | Remove 20' of back leg of existing machine to install/position Cryopmodules | manual | 5d | 2017-09-08 | 2017-09-14 | 3 | Inst./Vac | 40h |
| 60 | 4.2 | Remove Shielding Blocks | manual | 1d | 2017-09-11 | 2017-09-11 | 59 | Inst | 8h |
| 61 | 4.3 | Remove U-Tubes from FL02 & FL03 Cryomodules in LERF Vault | manual | 1d | 2017-09-01 | 2017-09-01 | 60 | Cryo | 8h |
| 62 | 4.4 | Remove U-tubes from FL04 & warm up | manual | 3d | 2017-10-02 | 2017-10-04 |  | Cryo | 24h |
| 63 | 4.5 | Remove waveguide and cabling from CM FL04 | manual | 4d | 2017-10-05 | 2017-10-10 | 62 | EESRF | 32h |
| 64 | 4.6 | Install clean room and secure clean vacuum on LERF cryomodules | manual | 6d | 2017-10-13 | 2017-10-20 | 63 | Vac/SRF | 48h |
| 65 | 4.7 | Move CM FL02 & FL03 to CEBAF linac | manual | 2d | 2017-10-24 | 2017-10-25 | 64 | Inst | 16h |
| 66 | 4.8 | Move CM FL04 to FL02 position | manual | 1d | 2017-10-26 | 2017-10-26 | 65 | Inst | 8h |
| 67 | 4.9 | Reconnect cryomodule in FL02 position | manual | 6d | 2017-10-27 | 2017-11-03 | 66 | EESRF | 48h |
| 68 | 4.10 | Locate and Install CM mounting plates | manual | 1d | 2017-10-30 | 2017-10-30 | 60, 32 | Inst | 8h |
| 69 | 4.11 | Align CM mounting plates | manual | 3d | 2017-11-01 | 2017-11-03 | 68 | Align | 24h |
| 70 | 4.12 | Installation of LLRF | manual | 43d | 2017-12-15 | 2018-02-13 | 46 |  |  |
| 71 | 4.13 | Installation of High Power SSAs in gallery | manual | 31d | 2018-01-15 | 2018-02-26 | 20 |  |  |
| 72 | 4.14 | Install waveguide in gallery | manual | 31d | 2017-12-14 | 2018-01-25 | 45 |  |  |
| 73 | 4.15 | Install and Check out Cabling | manual | 43d | 2017-12-12 | 2018-02-08 | 69 |  |  |
| 74 | 4.16 | Install First set of Cryomodules | manual | 35d | 2018-01-09 | 2018-02-26 | 76FF |  |  |
| 75 | 4.17 | Connect waveguide to cryomodules | manual | 4d | 2018-02-27 | 2018-03-02 | 74 |  |  |
| 76 | 4.18 | Install End Caps | manual | 17d | 2018-02-02 | 2018-02-26 | 25 |  |  |
| 77 | 4.19 | Connect mid-point connections on CMs | manual | 4d | 2018-02-05 | 2018-02-08 |  | SRF | 32h |
| 78 | 4.20 | Superconducting Magnet Test | manual | 8d | 2018-04-02 | 2018-04-11 | 3 | SRF | 64h |
| 79 | 4.21 | BPM Checkout with Vector Network Analyzer | manual | 16d | 2018-04-11 | 2018-05-02 | 3 | EESRF | 128h |
| 80 | 4.22 | Install Waveguides and Components | manual | 22d | 2018-01-16 | 2018-02-14 | 20 | EESRF | 176h |
| 81 | 4.23 | Install and Set-up Cryogenic Controls | manual | 10d | 2018-02-27 | 2018-03-12 | 55, 76 |  |  |
| 82 | 4.24 | Safety System Tie in to PPS | manual | 25d | 2017-12-22 | 2018-01-25 | 37 |  |  |
| 83 | 4.25 | Commission RF System into Shorts | manual | 21d | 2018-03-21 | 2018-04-18 | 53, 70, 71, 73, 80, 81 |  |  |
| 84 | 4.26 | Commission Cryo System | manual | 25d | 2018-03-13 | 2018-04-16 | 73, 74, 81 |  |  |
| 85 | 4.27 | ReInstall Shielding | manual | 5d | 2018-01-26 | 2018-02-01 | 82 |  |  |
| 86 | 4.28 | Decarad and Faraday cups for Radiation monitoring | manual | 50d | 2017-10-03 | 2017-12-11 | 2 |  |  |

| ID | WBS | Task | Type | Duration | Start | Finish | Predecessors | Constraint |
| --- | --- | --- | --- | --- | --- | --- | --- | --- |
| 87 | 5 | **CEBAF Operations** |  | 303d | 2018-05-09 | 2019-07-05 |  |  |
| 88 | 5.1 | CEBAF Low Energy Summer Run | manual | 42d | 2018-05-09 | 2018-07-05 |  | start no earlier than 2018-05-09 |
| 89 | 5.2 | CEBAF Down | manual | 61d | 2018-07-06 | 2018-09-28 | 88 |  |
| 90 | 5.3 | CEBAF FY19 10 Week Run | manual | 60d | 2018-10-01 | 2018-12-21 | 89 |  |
| 91 | 5.4 | CEBAF Down | manual | 30d | 2018-12-24 | 2019-02-01 | 90 |  |
| 92 | 5.5 | CEBAF FY19 6 Week Run | manual | 41d | 2019-02-04 | 2019-04-01 | 91 |  |
| 93 | 5.6 | CEBAF Down | manual | 27d | 2019-04-02 | 2019-05-08 | 92 |  |
| 94 | 5.7 | CEBAF FY19 Low Energy Summer Run | manual | 42d | 2019-05-09 | 2019-07-05 | 93 |  |
| 95 | 6 | **Cryomodule Testing** |  | 337d | 2018-07-06 | 2019-10-21 |  |  |
| 96 | 6.1 | Two Cryomodule Testing | manual | 43d | 2018-07-06 | 2018-09-04 | 13, 49, 51, 57, 61, 69, 73, 74, 78, 79, 81, 84, 85, 86, 88 |  |
| 97 | 6.2 | ESS Testing Support | manual | 43d | 2018-07-06 | 2018-09-04 | 96SS |  |
| 98 | 6.3 | LERF Testing Support and Training | manual | 43d | 2018-07-06 | 2018-09-04 | 97SS |  |
| 99 | 6.4 | LERF Operating Costs | manual | 43d | 2018-07-06 | 2018-09-04 | 98SS |  |
| 100 | 6.5 | De-Installation | manual | 10d | 2018-09-05 | 2018-09-18 | 99 |  |
| 101 | 6.6 | Train Second Testing Crew | manual | 20d | 2018-09-19 | 2018-10-16 | 100 |  |
| 102 | 6.7 | Install Second set of Cryomodules | manual | 25d | 2018-09-19 | 2018-10-23 | 101SS |  |
| 103 | 6.8 | Two Cryomodule Testing | manual | 45d | 2018-12-24 | 2019-02-22 | 102, 90 |  |
| 104 | 6.9 | LERF Testing Support | manual | 45d | 2018-12-24 | 2019-02-22 | 103SS |  |
| 105 | 6.10 | LERF Operating Costs | manual | 45d | 2018-12-24 | 2019-02-22 | 104SS |  |
| 106 | 6.11 | De-Installation | manual | 15d | 2019-02-25 | 2019-03-15 | 105 |  |
| 107 | 6.12 | Install Third set of Cryomodules | manual | 25d | 2019-03-18 | 2019-04-19 | 106 |  |
| 108 | 6.13 | Two Cryomodule Testing | manual | 38d | 2019-04-22 | 2019-06-12 | 107, 92 |  |
| 109 | 6.14 | LERF Testing Support | manual | 38d | 2019-04-22 | 2019-06-12 | 108SS |  |
| 110 | 6.15 | LERF Operating Costs | manual | 38d | 2019-04-22 | 2019-06-12 | 109SS |  |
| 111 | 6.16 | De-Installation | manual | 15d | 2019-06-13 | 2019-07-03 | 110 |  |
| 112 | 6.17 | Install Fourth set of Cryomodules | manual | 25d | 2019-07-04 | 2019-08-07 | 111 |  |
| 113 | 6.18 | Two Cryomodule Testing | manual | 38d | 2019-08-08 | 2019-09-30 | 112, 94 |  |
| 114 | 6.19 | LERF Testing Support | manual | 38d | 2019-08-08 | 2019-09-30 | 113SS |  |
| 115 | 6.20 | LERF Operating Costs | manual | 38d | 2019-08-08 | 2019-09-30 | 114SS |  |
| 116 | 6.21 | De-Installation | manual | 15d | 2019-10-01 | 2019-10-21 | 115 |  |
| 117 | 6.22 | Misc Tooling to Support Repeated Tests | manual | 322d | 2018-07-06 | 2019-09-30 | 96SS |  |

| ID | WBS | Task | Type | Duration | Start | Finish | Predecessors |
| --- | --- | --- | --- | --- | --- | --- | --- |
| 118 | 7 | **Project Closeout and Restoration of LERF** |  | 61d? | 2019-10-22 | 2020-01-14 |  |
| 119 | 7.1 | Remove and Return LCLS II Equipment | manual | 60d | 2019-10-22 | 2020-01-13 | 116 |
| 120 | 7.2 | Restore LERF RF and SS to Pre LCLS II Configuration | manual | 40d | 2019-10-22 | 2019-12-16 | 116 |
| 121 | 7.3 | Restore LERF Linac and Vacuum Systems | manual | 40d | 2019-10-22 | 2019-12-16 | 116 |
| 122 | 7.4 | LERF LCLS II Testing Complete | manual | 1d? | 2020-01-14 | 2020-01-14 | 119, 120, 121 |
